# LLMsystemDevelopment

Schedule from MS Project, 2010-02-22 to 2010-04-09.
privat

## Calendars

- Standard: Mon-Fri 08:00-12:00, 13:00-17:00; Sat-Sun off.

## Schedule

| ID | WBS | Task | Type | Duration | Start | Finish | Predecessors | Total slack | Free slack | Constraint |
| --- | --- | --- | --- | --- | --- | --- | --- | --- | --- | --- |
| 2 | 1 | Start of development, iteration 1 | milestone | 0d | 2010-02-22 | 2010-02-22 |  | 0d |  | start no earlier than 2010-02-22 |
| 3 | 2 | Start of iteration 2 | milestone | 0d | 2010-03-08 | 2010-03-08 |  | 25d |  | start no earlier than 2010-03-08 |
| 4 | 3 | Start of iteration 3 | milestone | 0d | 2010-03-22 | 2010-03-22 |  | 15d |  | start no earlier than 2010-03-22 |
| 5 | 4 | **LLM system development** |  | 35d | 2010-02-22 | 2010-04-09 |  | 0d |  |  |
| 6 | 4.1 | LLF |  | 10d | 2010-02-22 | 2010-03-05 | 2 | 5d | 0d |  |
| 7 | 4.2 | LLM-DB |  | 15d | 2010-02-22 | 2010-03-12 | 2 | 0d |  |  |
| 8 | 4.3 | CTC-Integration |  | 10d | 2010-02-22 | 2010-03-05 | 2 | 25d |  |  |
| 9 | 4.4 | CTC-LUI-Integration |  | 5d | 2010-03-08 | 2010-03-12 | 6 | 20d |  |  |
| 10 | 4.5 | PTC-Integration |  | 10d | 2010-03-15 | 2010-03-26 | 7 | 10d |  |  |
| 11 | 4.6 | ILC-Integration |  | 15d | 2010-02-22 | 2010-03-12 | 2 | 20d |  |  |
| 12 | 4.7 | RUI-Framework |  | 5d | 2010-02-22 | 2010-02-26 | 2 | 0d |  |  |
| 13 | 4.8 | LLM-LUI screens |  | 5d | 2010-03-08 | 2010-03-12 | 6 | 20d |  |  |
| 14 | 4.9 | CMS-LUI screens |  | 5d | 2010-03-08 | 2010-03-12 | 6 | 20d |  |  |
| 15 | 4.10 | Workflow-LUI screens |  | 5d | 2010-03-08 | 2010-03-12 | 6 | 20d |  |  |
| 16 | 4.11 | Workflow CMS service code |  | 10d | 2010-03-01 | 2010-03-12 | 12 | 20d |  |  |
| 17 | 4.12 | Specific RUI object editors |  | 15d | 2010-03-01 | 2010-03-19 | 12 | 5d | 0d |  |
| 18 | 4.13 | LRF |  | 15d | 2010-03-01 | 2010-03-19 | 12 | 0d |  |  |
| 19 | 4.14 | LRF plugins (2 samples) |  | 15d | 2010-03-22 | 2010-04-09 | 18 | 0d |  |  |
| 20 | 4.15 | non-editor CMS RUI code |  | 15d | 2010-03-01 | 2010-03-19 | 12 | 15d |  |  |
| 21 | 4.16 | Generic RUI object editor |  | 10d | 2010-03-22 | 2010-04-02 | 17 | 5d |  |  |
| 22 | 4.17 | DB local replication |  | 10d | 2010-03-15 | 2010-03-26 | 7 | 0d |  |  |
| 23 | 4.18 | DB global replication |  | 10d | 2010-03-29 | 2010-04-09 | 22 | 0d |  |  |
| 24 | 4.19 | LUI and LRF localization concept |  | 10d | 2010-03-08 | 2010-03-19 | 6 | 5d | 0d |  |
| 25 | 4.20 | LUI and LRF localization |  | 10d | 2010-03-22 | 2010-04-02 | 24 | 5d |  |  |
